# ProgrLavCertaldo r02

Schedule from MS Project, 2006-11-07 to 2009-06-30, status date 2006-11-10.

## Calendars

- Standard: Mon-Sun 09:00-13:00, 14:00-18:00.
- APERTO 22 gg: Mon-Fri 09:00-13:00, 14:00-18:00; Sat-Sun off.

## Schedule

| ID | WBS | Task | Type | Duration | Start | Finish | Predecessors | Total slack | Free slack | Constraint | Calendar |
| --- | --- | --- | --- | --- | --- | --- | --- | --- | --- | --- | --- |
| 2 | 1 | **VARIANTE DI CERTALDO** |  | 967d? | 2006-11-07 | 2009-06-30 |  | 0d |  |  |  |
| 3 | 1.1 | RICHIESTA SUBENTRO CSI AD ANAS | milestone | 0d | 2006-11-07 | 2006-11-07 |  | 32d | 0d |  |  |
| 4 | 1.2 | AUTORIZZAZIONE AL SUBENTRO (C.S.I.) DA PARTE DI ANAS | milestone | 0d | 2007-02-04 | 2007-02-04 | 3FS+90d | 32d |  |  |  |
| 5 | 1.3 | RIPRESA LAVORI | milestone | 0d | 2007-01-08 | 2007-01-08 |  | 0d |  | start no earlier than 2007-01-08 |  |
| 6 | 1.4 | **CANTIERIZZAZIONE** |  | 60d | 2007-01-08 | 2007-03-08 |  | 0d |  |  |  |
| 7 | 1.4.1 | OPERE PROPEDEUTICHE (Autoriz e Concessioni) |  | 60d | 2007-01-08 | 2007-03-08 | 5 | 0d |  |  |  |
| 8 | 1.4.2 | RIAVVIO CANTIERE |  | 50d | 2007-01-18 | 2007-03-08 | 7SS+10d | 122d | 0d |  |  |
| 9 | 1.4.3 | RIPRISTINO PISTE CANTIERE |  | 30d | 2007-02-07 | 2007-03-08 | 8SS+20d | 122d | 0d |  |  |
| 10 | 1.4.4 | PROGETTO RIUTILIZZO MAT SCAVO |  | 60d | 2007-01-08 | 2007-03-08 | 7SS | 0d |  |  |  |
| 11 | 1.4.5 | POS + SISTEMA GESTIONE EMERGENZE |  | 60d | 2007-01-08 | 2007-03-08 | 7SS | 0d |  |  |  |
| 12 | 1.5 | **ASSE A** |  | 119d | 2008-09-16 | 2009-02-27 |  | 87d |  |  | APERTO 22 gg |
| 13 | 1.5.1 | SBANCAMENTO / P. P. Posa |  | 22d | 2008-09-16 | 2008-10-15 | 42 | 87d | 4d |  | APERTO 22 gg |
| 14 | 1.5.2 | TOMBINI CIRCOLARI / SCATOLARI |  | 18d | 2008-09-30 | 2008-10-23 | 13SS+10d | 87d | 0d |  | APERTO 22 gg |
| 15 | 1.5.3 | RILEVATI |  | 55d | 2008-10-08 | 2008-12-23 | 14FS-12d | 87d | 0d |  | APERTO 22 gg |
| 16 | 1.5.4 | **PACCHETTO STRADALE** |  | 28d | 2008-12-18 | 2009-01-26 |  | 87d |  |  | APERTO 22 gg |
| 17 | 1.5.4.1 | Misto stabilizzato sp 25 cm |  | 12d | 2008-12-18 | 2009-01-02 | 15FS-4d | 87d | 2d |  | APERTO 22 gg |
| 18 | 1.5.4.2 | Misto cementato sp 20 cm |  | 10d | 2009-01-05 | 2009-01-16 | 17 | 87d | 2d |  | APERTO 22 gg |
| 19 | 1.5.4.3 | Conglomerato bituminoso BASE |  | 6d | 2009-01-19 | 2009-01-26 | 18 | 111d |  |  | APERTO 22 gg |
| 20 | 1.5.5 | IMPIANTISTICA ILLUMINAZIONE |  | 30d | 2009-01-19 | 2009-02-27 | 18 | 87d |  |  | APERTO 22 gg |
| 21 | 1.5.6 | SIST ESTERNE (VEGETALE, EMBRICI, BARRIERE) |  | 25d | 2008-12-24 | 2009-01-27 | 15 | 110d |  |  | APERTO 22 gg |
| 22 | 1.6 | **VIADOTTO SULL'ELSA** |  | 504d | 2007-01-08 | 2008-12-11 |  | 143d |  |  | APERTO 22 gg |
| 23 | 1.6.1 | AUTORIZ ED ESECUZ PASSAGGIO A LIVELLO PROVVISSORIO |  | 90d | 2007-01-08 | 2007-05-11 | 5 | 192d | 2d |  | APERTO 22 gg |
| 24 | 1.6.2 | RICHIESTA E FABBRICAZ DELLE TRAVI |  | 60d | 2007-05-14 | 2007-08-03 | 23 | 192d | 142d |  | APERTO 22 gg |
| 25 | 1.6.3 | COMPLETAMENTO PALIFICATA |  | 20d | 2007-04-06 | 2007-05-03 | 47 | 222d | 0d |  | APERTO 22 gg |
| 26 | 1.6.4 | SCAVI PLINTI |  | 20d | 2007-04-23 | 2007-05-18 | 25FS-9d | 222d | 184d |  | APERTO 22 gg |
| 27 | 1.6.5 | FONDAZIONE |  | 30d | 2007-10-29 | 2007-12-07 | 26SS+5d, 50 | 92d | 8d |  | APERTO 22 gg |
| 28 | 1.6.6 | ELEVAZIONE |  | 70d | 2007-11-26 | 2008-02-29 | 27SS+20d | 92d | 0d |  | APERTO 22 gg |
| 29 | 1.6.7 | VARO TRAVI CAP |  | 70d | 2007-12-24 | 2008-03-28 | 24, 28FS-50d | 92d | 0d |  | APERTO 22 gg |
| 30 | 1.6.8 | ESECUZIONE TRASVERSI |  | 35d | 2008-02-25 | 2008-04-11 | 29FS-25d | 92d | 10d |  | APERTO 22 gg |
| 31 | 1.6.9 | SOLETTA |  | 105d | 2008-04-22 | 2008-09-15 | 30, 53 | 86d | 0d |  | APERTO 22 gg |
| 32 | 1.6.10 | OPERE COMPLETAMENTO (BARRIERE SIC + ANTIRUM) |  | 30d | 2008-09-08 | 2008-10-17 | 31FS-6d | 143d | 0d |  | APERTO 22 gg |
| 33 | 1.6.11 | IMPERMEABILIZZAZIONE |  | 38d | 2008-10-13 | 2008-12-03 | 32FS-5d | 143d | 0d |  | APERTO 22 gg |
| 34 | 1.6.12 | BINDER |  | 6d | 2008-12-04 | 2008-12-11 | 33 | 143d |  |  | APERTO 22 gg |

Notes:
- 13: 21.743 mq
- 14: n° 5
- 15: 50
- 17: 5.178 mc
- 18: 4.025 mc
- 19: 1.894 mq
- 25: ·Palificazione ultimata ad eccezione Pila 2 e 1A
- 26: ·Gli scavi interrotti

| ID | WBS | Task | Duration | Start | Finish | Predecessors | Total slack | Free slack | Calendar |
| --- | --- | --- | --- | --- | --- | --- | --- | --- | --- |
| 35 | 1.7 | **ASSE B** | 205d | 2008-01-29 | 2008-11-10 |  | 87d |  | APERTO 22 gg |
| 36 | 1.7.1 | SBANCAMENTO / P. P. Posa | 30d | 2008-01-29 | 2008-03-10 | 161 | 87d | 4d | APERTO 22 gg |
| 37 | 1.7.2 | PONTICELLI | 40d | 2008-06-17 | 2008-08-11 | 38 | 231d |  | APERTO 22 gg |
| 38 | 1.7.3 | TOMBINI CIRCOLARI / SCATOLARI | 90d | 2008-02-12 | 2008-06-16 | 36SS+10d | 87d | 0d | APERTO 22 gg |
| 39 | 1.7.4 | RILEVATI | 55d | 2008-05-30 | 2008-08-14 | 38FS-12d | 87d | 0d | APERTO 22 gg |
| 40 | 1.7.5 | **PACCHETTO STRADALE** | 36d | 2008-08-11 | 2008-09-29 |  | 87d |  | APERTO 22 gg |
| 41 | 1.7.5.1 | Misto stabilizzato sp 25 cm | 15d | 2008-08-11 | 2008-08-29 | 39FS-4d | 87d | 2d | APERTO 22 gg |
| 42 | 1.7.5.2 | Misto cementato sp 20 cm | 11d | 2008-09-01 | 2008-09-15 | 41 | 87d | 0d | APERTO 22 gg |
| 43 | 1.7.5.3 | Conglomerato bituminoso BASE | 10d | 2008-09-16 | 2008-09-29 | 42 | 196d |  | APERTO 22 gg |
| 44 | 1.7.6 | IMPIANTISTICA ILLUMINAZIONE SVINCOLI | 40d | 2008-09-16 | 2008-11-10 | 42 | 166d |  | APERTO 22 gg |
| 45 | 1.7.7 | SIST ESTERNE (VEGETALE, EMBRICI, BARRIERE) | 40d | 2008-08-15 | 2008-10-09 | 39 | 188d |  | APERTO 22 gg |
| 46 | 1.8 | **VIADOTTO ARTIGIANALE** | 334d | 2007-03-09 | 2008-06-18 |  | 92d |  | APERTO 22 gg |
| 47 | 1.8.1 | COMPLETAMENTO PALIFICATA | 20d | 2007-03-09 | 2007-04-05 | 7, 8, 9, 10 | 92d | 0d | APERTO 22 gg |
| 48 | 1.8.2 | SCAVI PLINTI | 70d | 2007-03-26 | 2007-06-29 | 47FS-9d | 92d | 2d | APERTO 22 gg |
| 49 | 1.8.3 | FONDAZIONE | 90d | 2007-04-02 | 2007-08-03 | 48SS+5d | 92d | 8d | APERTO 22 gg |
| 50 | 1.8.4 | ELEVAZIONE | 130d | 2007-04-30 | 2007-10-26 | 49SS+20d | 92d | 2d | APERTO 22 gg |
| 51 | 1.8.5 | VARO TRAVI CORTEN | 35d | 2007-10-29 | 2007-12-14 | 50 | 97d | 2d | APERTO 22 gg |
| 52 | 1.8.6 | CONTROLLO SERRAGGI BULLONI TRAVI ACCIAIO | 3d | 2007-12-17 | 2007-12-19 | 51 | 97d | 15d | APERTO 22 gg |
| 53 | 1.8.7 | SOLETTA | 77d | 2008-01-04 | 2008-04-21 | 52, 168 | 86d | 0d | APERTO 22 gg |
| 54 | 1.8.8 | OPERE COMPLETAMENTO (BARRIERE SIC + ANTIRUM) | 20d | 2008-04-14 | 2008-05-09 | 53FS-6d | 269d | 0d | APERTO 22 gg |
| 55 | 1.8.9 | IMPERMEABILIZZAZIONE | 30d | 2008-05-05 | 2008-06-13 | 54FS-5d | 269d | 2d | APERTO 22 gg |
| 56 | 1.8.10 | BINDER | 3d | 2008-06-16 | 2008-06-18 | 55 | 269d |  | APERTO 22 gg |
| 57 | 1.9 | **GALLERIA MARCIGNANO** | 844d | 2007-03-09 | 2009-06-29 |  | 1d |  |  |
| 58 | 1.9.1 | **IMBOCCO EMPOLI** | 59d | 2007-03-09 | 2007-05-06 |  | 0d |  |  |
| 59 | 1.9.1.1 | PALIFICATA + TRAVI DI CORONAM | 10d | 2007-03-09 | 2007-03-18 | 7, 4 | 5d |  |  |
| 60 | 1.9.1.2 | SCAVO IMBOCCO | 15d | 2007-03-24 | 2007-04-07 | 59, 89 | 0d |  |  |
| 61 | 1.9.1.3 | DEMOLIZIONE PALI FRONTE + PRIMO INTERVENTO CONSOL. | 15d | 2007-04-08 | 2007-04-22 | 60 | 0d |  |  |
| 62 | 1.9.1.4 | COSTRUZIONE DIMA | 14d | 2007-04-23 | 2007-05-06 | 61 | 0d |  |  |

Notes:
- 36: 29.948 mq
- 38: n° 37
- 39: 43.800 mc
- 41: 7032 mc
- 42: 5400 mc
- 43: 24748 mq
- 47: ·Palificazione ultimata ad eccezione Pila 2 e 1A
- 48: ·Gli scavi interrotti
- 59: ·Palificata eseguita / ·Da eseguire: travi di coronamento

| ID | WBS | Task | Duration | Start | Finish | Predecessors | Total slack | Free slack | Calendar |
| --- | --- | --- | --- | --- | --- | --- | --- | --- | --- |
| 63 | 1.9.2 | **GALLERIA ARTIFICIALE LATO EMPOLI** | 40d | 2007-06-06 | 2007-07-15 |  | 0d |  |  |
| 64 | 1.9.2.1 | REALIZZAZIONE GALLERIA ARTIFICIALE IMBOCCO LATO EMPOLI (BECCO DI FLAUTO) | 40d | 2007-06-06 | 2007-07-15 | 62FS+30d | 0d |  |  |
| 65 | 1.9.3 | **GALLERIA NATURALE** | 785d | 2007-05-07 | 2009-06-29 |  | 1d |  |  |
| 66 | 1.9.3.1 | SCAVO+CONSOLID+CENTINAT | 720d | 2007-05-07 | 2009-04-25 | 10, 62 | 15d | 0d |  |
| 67 | 1.9.3.2 | ARCO ROVESCIO + MURETTE | 720d | 2007-05-15 | 2009-05-03 | 66SS+8d | 15d | 0d |  |
| 68 | 1.9.3.3 | IMPERMEABILIZZAZIONE | 720d | 2007-05-30 | 2009-05-18 | 67SS+15d | 43d |  |  |
| 69 | 1.9.3.4 | RIVESTIMENTO IN CLS | 686d | 2007-07-16 | 2009-05-31 | 64 | 0d |  |  |
| 70 | 1.9.3.5 | SOVRASTRUTTURA + DRENAGGIO ARCO ROVESCIO | 220d | 2008-11-22 | 2009-06-29 | 77FF+5d | 1d |  |  |
| 71 | 1.9.3.6 | **IMBOCCO POGGIBONSI** | 56d | 2009-02-20 | 2009-04-16 |  | 75d |  |  |
| 72 | 1.9.3.6.1 | PALIFICATA + TRAVI DI CORONAM | 20d | 2009-02-20 | 2009-03-11 | 66FF-45d | 75d | 0d |  |
| 73 | 1.9.3.6.2 | SCAVO | 15d | 2009-03-12 | 2009-03-26 | 72 | 75d | 0d |  |
| 74 | 1.9.3.6.3 | DEMOLIZIONE PALI FRONTE | 7d | 2009-03-27 | 2009-04-02 | 73 | 75d | 0d |  |
| 75 | 1.9.3.6.4 | COSTRUZIONE DIMA | 14d | 2009-04-03 | 2009-04-16 | 74 | 75d |  |  |
| 76 | 1.9.4 | **GALLERIA ARTIFICIALE LATO POGGIBONSI** | 24d | 2009-06-01 | 2009-06-24 |  | 1d |  |  |
| 77 | 1.9.4.1 | REALIZZAZIONE GALLERIA ARTIFICIALE IMBOCCO LATO POGGIBONSI (BECCO DI FLAUTO) | 24d | 2009-06-01 | 2009-06-24 | 69 | 1d | 0d |  |
| 78 | 1.9.5 | **OPERE COMPLETAMENTO** | 29d | 2009-06-01 | 2009-06-29 |  | 0d |  |  |
| 79 | 1.9.5.1 | IMPIANTISTICA | 24d | 2009-06-01 | 2009-06-24 | 69 | 0d |  |  |
| 80 | 1.9.5.2 | CONGLOMERATI BITUMINOSI | 5d | 2009-06-25 | 2009-06-29 | 79 | 0d |  |  |
| 81 | 1.10 | **VIADOTTO CASCIANI** | 61d | 2007-09-07 | 2007-11-30 |  | 88d |  | APERTO 22 gg |
| 82 | 1.10.1 | CONTROLLO SERRAGGI BULLONI TRAVI ACCIAIO | 3d | 2007-09-07 | 2007-09-11 | 151FS-5d | 88d | 2d | APERTO 22 gg |
| 83 | 1.10.2 | SOLETTA | 40d | 2007-09-14 | 2007-11-08 | 82, 151 | 86d | 0d | APERTO 22 gg |
| 84 | 1.10.3 | OPERE COMPLETAMENTO (BARRIERE SIC + ANTIRUM) | 10d | 2007-11-01 | 2007-11-14 | 83FS-6d | 412d | 0d | APERTO 22 gg |
| 85 | 1.10.4 | IMPERMEABILIZZAZIONE | 15d | 2007-11-08 | 2007-11-28 | 84FS-5d | 412d | 0d | APERTO 22 gg |
| 86 | 1.10.5 | BINDER | 2d | 2007-11-29 | 2007-11-30 | 85 | 412d |  | APERTO 22 gg |

| ID | WBS | Task | Duration | Start | Finish | Predecessors | Total slack | Free slack | Calendar |
| --- | --- | --- | --- | --- | --- | --- | --- | --- | --- |
| 87 | 1.11 | **GALLERIA FOGNETO I** | 469d | 2007-03-09 | 2008-06-19 |  | 0d |  |  |
| 88 | 1.11.1 | **IMBOCCO POGGIBONSI** | 44d | 2007-03-09 | 2007-04-21 |  | 0d |  |  |
| 89 | 1.11.1.1 | SCAVO IMBOCCO | 15d | 2007-03-09 | 2007-03-23 | 7, 10, 11, 4 | 0d |  |  |
| 90 | 1.11.1.2 | DEMOLIZIONE PALI FRONTE + PRIMO INTERVENTO CONSOL. | 15d | 2007-03-24 | 2007-04-07 | 89 | 1d | 0d |  |
| 91 | 1.11.1.3 | COSTRUZIONE DIMA | 14d | 2007-04-08 | 2007-04-21 | 90 | 1d | 0d |  |
| 92 | 1.11.2 | **GALLERIA ARTIFICIALE LATO POGGIBONSI** | 40d | 2007-05-22 | 2007-06-30 |  | 376d |  |  |
| 93 | 1.11.2.1 | REALIZZAZIONE GALLERIA ARTIFICIALE IMBOCCO LATO POGGIBONSI (BECCO DI FLAUTO) | 40d | 2007-05-22 | 2007-06-30 | 91FS+30d | 376d | 0d |  |
| 94 | 1.11.3 | **GALLERIA NATURALE** | 415d | 2007-04-22 | 2008-06-09 |  | 1d |  |  |
| 95 | 1.11.3.1 | SCAVO+CONSOLID+CENTINAT | 320d | 2007-04-22 | 2008-03-06 | 91 | 1d | 0d |  |
| 96 | 1.11.3.2 | ARCO ROVESCIO + MURETTE | 320d | 2007-04-30 | 2008-03-14 | 95SS+8d | 458d | 0d |  |
| 97 | 1.11.3.3 | IMPERMEABILIZZAZIONE | 320d | 2007-05-15 | 2008-03-29 | 96SS+15d | 458d |  |  |
| 98 | 1.11.3.4 | RIVESTIMENTO IN CLS | 290d | 2007-07-01 | 2008-04-15 | 93 | 376d | 0d |  |
| 99 | 1.11.3.5 | SOVRASTRUTTURA + DRENAGGIO ARCO ROVESCIO | 220d | 2007-11-03 | 2008-06-09 | 106FF+15d | 386d |  |  |
| 100 | 1.11.3.6 | **IMBOCCO EMPOLI** | 56d | 2008-01-02 | 2008-02-26 |  | 490d |  |  |
| 101 | 1.11.3.6.1 | TRAVI DI CORONAM | 20d | 2008-01-02 | 2008-01-21 | 95FF-45d | 490d | 0d |  |
| 102 | 1.11.3.6.2 | SCAVO | 15d | 2008-01-22 | 2008-02-05 | 101 | 490d | 0d |  |
| 103 | 1.11.3.6.3 | DEMOLIZIONE PALI FRONTE | 7d | 2008-02-06 | 2008-02-12 | 102 | 490d | 0d |  |
| 104 | 1.11.3.6.4 | COSTRUZIONE DIMA | 14d | 2008-02-13 | 2008-02-26 | 103 | 490d |  |  |
| 105 | 1.11.4 | **GALLERIA ARTIFICIALE LATO EMPOLI** | 40d | 2008-04-16 | 2008-05-25 |  | 386d |  |  |
| 106 | 1.11.4.1 | REALIZZAZIONE GALLERIA ARTIFICIALE IMBOCCO LATO EMPOLI (BECCO DI FLAUTO) | 40d | 2008-04-16 | 2008-05-25 | 98 | 386d | 0d |  |
| 107 | 1.11.5 | **OPERE COMPLETAMENTO** | 65d | 2008-04-16 | 2008-06-19 |  | 376d |  |  |
| 108 | 1.11.5.1 | IMPIANTISTICA | 60d | 2008-04-16 | 2008-06-14 | 98 | 376d | 0d |  |
| 109 | 1.11.5.2 | CONGLOMERATI BITUMINOSI | 5d | 2008-06-15 | 2008-06-19 | 108 | 376d |  |  |
| 110 | 1.12 | **PONTICELLO FI-FII** | 55d | 2007-12-07 | 2008-02-21 |  | 353d |  | APERTO 22 gg |
| 111 | 1.12.1 | SCAVO | 2d | 2007-12-07 | 2007-12-10 | 95FS-65d | 353d | 0d | APERTO 22 gg |
| 112 | 1.12.2 | SCAPITOZZATURA | 3d | 2007-12-11 | 2007-12-13 | 111 | 353d | 0d | APERTO 22 gg |
| 113 | 1.12.3 | FONDAZIONE | 8d | 2007-12-14 | 2007-12-25 | 112 | 353d | 0d | APERTO 22 gg |
| 114 | 1.12.4 | ELEVAZIONE | 25d | 2007-12-26 | 2008-01-29 | 113 | 353d | 0d | APERTO 22 gg |
| 115 | 1.12.5 | SOLETTA | 12d | 2008-01-30 | 2008-02-14 | 114 | 353d | 0d | APERTO 22 gg |
| 116 | 1.12.6 | FINITURE | 5d | 2008-02-15 | 2008-02-21 | 115 | 353d |  | APERTO 22 gg |

| ID | WBS | Task | Duration | Start | Finish | Predecessors | Total slack | Free slack | Calendar |
| --- | --- | --- | --- | --- | --- | --- | --- | --- | --- |
| 117 | 1.13 | **GALLERIA FOGNETO II** | 585d | 2007-11-22 | 2009-06-28 |  | 2d |  |  |
| 118 | 1.13.1 | **PROTESI** | 95d | 2007-11-22 | 2008-02-25 |  | 492d |  |  |
| 119 | 1.13.1.1 | PISTA DI ACCESSO + SCAVO | 22d | 2007-11-22 | 2007-12-24 | 120SF | 420d |  | APERTO 22 gg |
| 120 | 1.13.1.2 | PREPARAZIONE E GETTO C.A. | 18d | 2007-12-24 | 2008-01-17 | 121SF-15d | 402d | 0d | APERTO 22 gg |
| 121 | 1.13.1.3 | RINTERRO | 12d | 2008-02-07 | 2008-02-25 | 129SF-30d | 375d | 0d | APERTO 22 gg |
| 122 | 1.13.2 | **IMBOCCO EMPOLI** | 44d | 2008-02-21 | 2008-04-04 |  | 16d |  |  |
| 123 | 1.13.2.1 | SCAVO IMBOCCO | 15d | 2008-02-21 | 2008-03-07 | 124SF | 481d | 0d |  |
| 124 | 1.13.2.2 | DEMOLIZIONE PALI FRONTE + PRIMO INTERVENTO CONSOL. | 15d | 2008-03-07 | 2008-03-21 | 95 | 1d | 0d |  |
| 125 | 1.13.2.3 | COSTRUZIONE DIMA | 14d | 2008-03-22 | 2008-04-04 | 124 | 1d | 0d |  |
| 126 | 1.13.3 | **GALLERIA ARTIFICIALE LATO EMPOLI** | 25d | 2008-05-05 | 2008-05-29 |  | 1d |  |  |
| 127 | 1.13.3.1 | REALIZZAZIONE GALLERIA ARTIFICIALE IMBOCCO LATO EMPOLI (BECCO DI FLAUTO) | 25d | 2008-05-05 | 2008-05-29 | 125FS+30d | 1d | 0d |  |
| 128 | 1.13.4 | **GALLERIA NATURALE** | 449d | 2008-04-05 | 2009-06-27 |  | 3d |  |  |
| 129 | 1.13.4.1 | SCAVO+CONSOLID+CENTINAT | 390d | 2008-04-05 | 2009-04-29 | 125 | 11d | 0d |  |
| 130 | 1.13.4.2 | ARCO ROVESCIO + MURETTE | 390d | 2008-04-13 | 2009-05-07 | 129SS+8d | 11d | 0d |  |
| 131 | 1.13.4.3 | IMPERMEABILIZZAZIONE | 390d | 2008-04-28 | 2009-05-22 | 130SS+15d | 39d |  |  |
| 132 | 1.13.4.4 | RIVESTIMENTO IN CLS | 366d | 2008-05-30 | 2009-05-30 | 127 | 1d | 0d |  |
| 133 | 1.13.4.5 | SOVRASTRUTTURA + DRENAGGIO ARCO ROVESCIO | 180d | 2008-12-30 | 2009-06-27 | 140FF+2d | 3d |  |  |
| 134 | 1.13.4.6 | **IMBOCCO POGGIBONSI** | 56d | 2009-02-24 | 2009-04-20 |  | 71d |  |  |
| 135 | 1.13.4.6.1 | TRAVI DI CORONAM | 20d | 2009-02-24 | 2009-03-15 | 129FF-45d | 71d | 0d |  |
| 136 | 1.13.4.6.2 | SCAVO | 15d | 2009-03-16 | 2009-03-30 | 135 | 71d | 0d |  |
| 137 | 1.13.4.6.3 | DEMOLIZIONE PALI FRONTE | 7d | 2009-03-31 | 2009-04-06 | 136 | 71d | 0d |  |
| 138 | 1.13.4.6.4 | COSTRUZIONE DIMA | 14d | 2009-04-07 | 2009-04-20 | 137 | 71d |  |  |
| 139 | 1.13.5 | **GALLERIA ARTIFICIALE LATO POGGIBONSI** | 26d | 2009-05-31 | 2009-06-25 |  | 3d |  |  |
| 140 | 1.13.5.1 | REALIZZAZIONE GALLERIA ARTIFICIALE IMBOCCO LATO POGGIBONSI (BECCO DI FLAUTO) | 26d | 2009-05-31 | 2009-06-25 | 132 | 3d | 0d |  |

| ID | WBS | Task | Type | Duration | Start | Finish | Predecessors | Total slack | Free slack | Calendar |
| --- | --- | --- | --- | --- | --- | --- | --- | --- | --- | --- |
| 141 | 1.13.6 | **OPERE COMPLETAMENTO** |  | 29d | 2009-05-31 | 2009-06-28 |  | 1d |  |  |
| 142 | 1.13.6.1 | IMPIANTISTICA |  | 24d | 2009-05-31 | 2009-06-23 | 132 | 1d | 0d |  |
| 143 | 1.13.6.2 | CONGLOMERATI BITUMINOSI |  | 5d | 2009-06-24 | 2009-06-28 | 142 | 1d |  |  |
| 144 | 1.14 | **CAVALCAVIA VIGNACCE** |  | 85d | 2007-10-25 | 2008-02-21 |  | 354d |  | APERTO 22 gg |
| 145 | 1.14.1 | MOVIMENTO TERRA |  | 15d | 2007-10-25 | 2007-11-15 | 146SF | 424d |  | APERTO 22 gg |
| 146 | 1.14.2 | MISTO CEMENTATO A RIDOSSO SPALLE |  | 20d | 2007-11-15 | 2007-12-13 | 147SF | 404d | 0d | APERTO 22 gg |
| 147 | 1.14.3 | FINITURE |  | 45d | 2007-12-13 | 2008-02-14 | 148SF | 359d | 0d | APERTO 22 gg |
| 148 | 1.14.4 | DEVIAZIONE TRAFFICO SU NUOVO CAVALCAVIA | milestone | 5d | 2008-02-14 | 2008-02-21 | 123SF | 354d | 0d | APERTO 22 gg |
| 149 | 1.15 | **VIADOTTO FONDOVALLE ELSA** |  | 179d | 2007-03-09 | 2007-11-14 |  | 86d |  | APERTO 22 gg |
| 150 | 1.15.1 | CONTROLLO SERRAGGI BULLONI TRAVI ACCIAIO |  | 9d | 2007-03-09 | 2007-03-21 | 7, 8, 9 | 86d | 0d | APERTO 22 gg |
| 151 | 1.15.2 | SOLETTA |  | 126d | 2007-03-22 | 2007-09-13 | 150 | 86d | 0d | APERTO 22 gg |
| 152 | 1.15.3 | OPERE COMPLETAMENTO (BARRIERE SIC + ANTIRUM) |  | 20d | 2007-08-30 | 2007-09-26 | 151FS-11d | 411d | 0d | APERTO 22 gg |
| 153 | 1.15.4 | IMPERMEABILIZZAZIONE |  | 40d | 2007-09-14 | 2007-11-08 | 152FS-9d | 411d | 0d | APERTO 22 gg |
| 154 | 1.15.5 | BINDER |  | 4d | 2007-11-09 | 2007-11-14 | 153 | 424d |  | APERTO 22 gg |
| 155 | 1.16 | **RILEVATO F.ELSA-MULINAC** |  | 160d | 2007-07-03 | 2008-02-11 |  | 87d |  | APERTO 22 gg |
| 156 | 1.16.1 | SBANCAMENTO / P. P. Posa |  | 32d | 2007-07-03 | 2007-08-15 | 178 | 87d | 4d | APERTO 22 gg |
| 157 | 1.16.2 | TOMBINI CIRCOLARI / SCATOLARI |  | 45d | 2007-07-17 | 2007-09-17 | 156SS+10d | 87d | 0d | APERTO 22 gg |
| 158 | 1.16.3 | RILEVATI |  | 95d | 2007-08-31 | 2008-01-10 | 157FS-12d | 87d | 0d | APERTO 22 gg |
| 159 | 1.16.4 | **PACCHETTO STRADALE** |  | 19d | 2008-01-07 | 2008-01-31 |  | 87d |  | APERTO 22 gg |
| 160 | 1.16.4.1 | Misto stabilizzato sp 25 cm |  | 9d | 2008-01-07 | 2008-01-17 | 158FS-4d | 87d | 0d | APERTO 22 gg |
| 161 | 1.16.4.2 | Misto cementato sp 20 cm |  | 7d | 2008-01-18 | 2008-01-28 | 160 | 87d | 0d | APERTO 22 gg |
| 162 | 1.16.4.3 | Conglomerato bituminoso BASE |  | 3d | 2008-01-29 | 2008-01-31 | 161 | 368d |  | APERTO 22 gg |
| 163 | 1.16.5 | IMPIANTISTICA ILLUMINAZIONE |  | 10d | 2008-01-29 | 2008-02-11 | 161 | 361d |  | APERTO 22 gg |
| 164 | 1.16.6 | SIST ESTERNE (VEGETALE, EMBRICI, BARRIERE) |  | 20d | 2008-01-11 | 2008-02-07 | 158 | 363d |  | APERTO 22 gg |

Notes:
- 151: ·Eseguito al 5%
- 156: 31.200 mq
- 157: n° 18
- 158: 73.720 mc
- 160: 4105 mc
- 161: 3284 mc
- 162: 1642 mq

| ID | WBS | Task | Duration | Start | Finish | Predecessors | Total slack | Free slack | Calendar |
| --- | --- | --- | --- | --- | --- | --- | --- | --- | --- |
| 165 | 1.17 | **VIADOTTO MULINACCIO** | 231d | 2007-03-09 | 2008-01-25 |  | 228d |  | APERTO 22 gg |
| 166 | 1.17.1 | COMPLETAMENTO VARO TRAVI CORTEN | 30d | 2007-03-09 | 2007-04-19 | 7, 8, 9 | 228d | 0d | APERTO 22 gg |
| 167 | 1.17.2 | CONTROLLO SERRAGGI BULLONI TRAVI ACCIAIO | 3d | 2007-04-20 | 2007-04-24 | 166 | 228d | 198d | APERTO 22 gg |
| 168 | 1.17.3 | SOLETTA | 40d | 2007-11-09 | 2008-01-03 | 167, 83 | 86d | 0d | APERTO 22 gg |
| 169 | 1.17.4 | OPERE COMPLETAMENTO (BARRIERE SIC + ANTIRUM) | 10d | 2007-12-27 | 2008-01-09 | 168FS-6d | 372d | 0d | APERTO 22 gg |
| 170 | 1.17.5 | IMPERMEABILIZZAZIONE | 15d | 2008-01-03 | 2008-01-23 | 169FS-5d, 153 | 372d | 0d | APERTO 22 gg |
| 171 | 1.17.6 | BINDER | 2d | 2008-01-24 | 2008-01-25 | 170 | 372d |  | APERTO 22 gg |
| 172 | 1.18 | **RILEVATO PIAN DI SOTTO** | 56d | 2007-05-07 | 2007-07-23 |  | 87d |  | APERTO 22 gg |
| 173 | 1.18.1 | SBANCAMENTO / P. P. Posa | 14d | 2007-05-07 | 2007-05-24 | 188, 66SS, 95SS | 87d | 4d | APERTO 22 gg |
| 174 | 1.18.2 | TOMBINI CIRCOLARI / SCATOLARI | 5d | 2007-05-21 | 2007-05-25 | 173SS+10d | 87d | 0d | APERTO 22 gg |
| 175 | 1.18.3 | RILEVATI | 30d | 2007-05-10 | 2007-06-20 | 174FS-12d | 87d | 0d | APERTO 22 gg |
| 176 | 1.18.4 | **PACCHETTO STRADALE** | 15d | 2007-06-15 | 2007-07-05 |  | 87d |  | APERTO 22 gg |
| 177 | 1.18.4.1 | Misto stabilizzato sp 25 cm | 7d | 2007-06-15 | 2007-06-25 | 175FS-4d | 87d | 0d | APERTO 22 gg |
| 178 | 1.18.4.2 | Misto cementato sp 20 cm | 5d | 2007-06-26 | 2007-07-02 | 177 | 87d | 0d | APERTO 22 gg |
| 179 | 1.18.4.3 | Conglomerato bituminoso BASE | 3d | 2007-07-03 | 2007-07-05 | 178 | 518d |  | APERTO 22 gg |
| 180 | 1.18.5 | IMPIANTISTICA ILLUMINAZIONE | 15d | 2007-07-03 | 2007-07-23 | 178 | 506d |  | APERTO 22 gg |
| 181 | 1.18.6 | SIST ESTERNE (VEGETALE, EMBRICI, BARRIERE) | 20d | 2007-06-21 | 2007-07-18 | 175 | 509d |  | APERTO 22 gg |
| 182 | 1.19 | **AMPLIAMENTO STRADA COMUNALE + SVINCOLO** | 58d | 2007-03-09 | 2007-05-29 |  | 87d |  | APERTO 22 gg |
| 183 | 1.19.1 | SBANCAMENTO / P. P. Posa | 10d | 2007-03-09 | 2007-03-22 | 7, 8, 9, 10 | 87d | 4d | APERTO 22 gg |
| 184 | 1.19.2 | ALLUNGAMENTO TOMBINI CIRCOLARI / SCATOLARI | 20d | 2007-03-23 | 2007-04-19 | 183SS+10d | 87d | 0d | APERTO 22 gg |
| 185 | 1.19.3 | RILEVATI | 20d | 2007-04-04 | 2007-05-01 | 184FS-12d | 87d | 0d | APERTO 22 gg |
| 186 | 1.19.4 | **PACCHETTO STRADALE** | 10d | 2007-04-26 | 2007-05-09 |  | 87d |  | APERTO 22 gg |
| 187 | 1.19.4.1 | Misto stabilizzato sp 25 cm | 4d | 2007-04-26 | 2007-05-01 | 185FS-4d | 87d | 0d | APERTO 22 gg |
| 188 | 1.19.4.2 | Misto cementato sp 20 cm | 3d | 2007-05-02 | 2007-05-04 | 187 | 87d | 2d | APERTO 22 gg |
| 189 | 1.19.4.3 | Conglomerato bituminoso BASE | 3d | 2007-05-07 | 2007-05-09 | 188 | 559d |  | APERTO 22 gg |
| 190 | 1.19.5 | IMPIANTISTICA ILLUMINAZIONE | 15d | 2007-05-07 | 2007-05-25 | 188 | 547d |  | APERTO 22 gg |
| 191 | 1.19.6 | SIST ESTERNE (VEGETALE, EMBRICI, BARRIERE) | 20d | 2007-05-02 | 2007-05-29 | 185 | 545d |  | APERTO 22 gg |

Notes:
- 173: 14.000 mq
- 174: ?????
- 175: 23.315 mc
- 177: 3000 mc
- 178: 2400 mc
- 179: 1253 mq
- 183: 5.500 mq
- 185: 9.400 mc
- 187: 1000 mc
- 188: 802 mc
- 189: 348 mq

| ID | WBS | Task | Type | Duration | Start | Finish | Predecessors | Total slack | Constraint | Calendar |
| --- | --- | --- | --- | --- | --- | --- | --- | --- | --- | --- |
| 192 | 1.20 | **OPERE DI CONSOLID. E PROTEZ.** |  | 206d | 2008-09-16 | 2009-06-30 |  | 0d |  | APERTO 22 gg |
| 193 | 1.20.1 | PROTEZ FONDOVALLE ELSA |  | 120d | 2008-09-16 | 2009-03-02 | 31 | 86d |  | APERTO 22 gg |
| 194 | 1.20.2 | PROTEZ TESTATE TOMBINI |  | 40d | 2008-10-24 | 2008-12-18 | 14 | 137d |  | APERTO 22 gg |
| 195 | 1.20.3 | PROTEZ PIEDE RILEVATO |  | 45d | 2008-12-24 | 2009-02-24 | 15 | 90d |  | APERTO 22 gg |
| 196 | 1.20.4 | PROTEZ TORRENTE CASCIANI |  | 30d | 2009-05-08 | 2009-06-18 | 67, 130 | 7d |  | APERTO 22 gg |
| 197 | 1.20.5 | SMOBILIZZO CANTIERE |  | 20d | 2009-06-11 | 2009-06-30 | 198FF | 0d |  |  |
| 198 | 1.21 | FINE LAVORI | milestone | 1d? | 2009-06-30 | 2009-06-30 | 143, 80, 196, 194 | 0d |  |  |
| 199 | 1.22 | TERMINE CONTRATTUALE | milestone | 1d? | 2009-03-31 | 2009-03-31 |  | 0d | must start on 2009-03-31 |  |
| 200 | 1.23 | SLITTAMENTO TERMINI CONTRATTUALI | milestone | 1d? | 2009-06-30 | 2009-06-30 | 199FS+90d | 1d |  |  |
